# DOL Project Plan3

Schedule from MS Project, 2003-11-03 to 2004-03-01.
Jordan Enterprises Group

## Calendars

- Standard: Mon-Fri 08:00-12:00, 13:00-17:00; Sat-Sun off.

## Schedule

| ID | WBS | Task | Type | Duration | Start | Finish | Predecessors | Baseline start | Baseline finish | Baseline duration | Total slack | Free slack | Constraint |
| --- | --- | --- | --- | --- | --- | --- | --- | --- | --- | --- | --- | --- | --- |
| 1 | 1 | Project Plan | milestone | 0d | 2003-11-04 | 2003-11-04 |  | 2003-10-29 | 2003-11-07 | 8d | 84d |  | start no earlier than 2003-11-04 |
| 2 | 2 | Kickoff Meeting |  | 1d | 2003-11-06 | 2003-11-06 |  | 2003-11-06 | 2003-11-06 | 1d | 95d |  | start no earlier than 2003-11-06 |
| 3 | 3 | Data Call |  | 15d | 2003-11-03 | 2003-11-21 |  | 2003-11-03 | 2003-11-21 | 15d | 44d | 0d |  |
| 4 | 4 | **Require/Config Analysis** |  | 55d | 2003-11-03 | 2004-01-16 |  | 2003-11-03 | 2004-01-16 | 55d | 30d |  |  |
| 5 | 4.1 | Data Analysis-Reference data |  | 20d | 2003-11-03 | 2003-11-28 |  | 2003-11-03 | 2003-11-28 | 20d | 79d |  |  |
| 6 | 4.2 | Data Analysis-Acct/amt data |  | 30d | 2003-11-10 | 2003-12-19 |  | 2003-11-10 | 2003-12-19 | 30d | 64d |  | start no earlier than 2003-11-10 |
| 7 | 4.3 | Data Structure Configuration |  | 30d | 2003-11-17 | 2003-12-26 |  | 2003-11-17 | 2003-12-26 | 30d | 59d |  | start no earlier than 2003-11-17 |
| 8 | 4.4 | Data Conversion |  | 40d | 2003-11-24 | 2004-01-16 | 3 | 2003-11-24 | 2004-01-16 | 40d | 44d |  |  |
| 9 | 4.5 | Data Business Rules |  | 15d | 2003-11-24 | 2003-12-12 |  | 2003-11-24 | 2003-12-12 | 15d | 69d |  | start no earlier than 2003-11-24 |
| 10 | 5 | **Business Procedures Analysis** |  | 25d | 2003-11-03 | 2003-12-05 |  | 2003-11-03 | 2003-12-05 | 25d | 60d |  |  |
| 11 | 5.1 | Document Review/Interviews |  | 15d | 2003-11-03 | 2003-11-21 |  | 2003-11-03 | 2003-11-21 | 15d | 84d |  |  |
| 12 | 5.2 | Procedural Bus. Rules Analysis |  | 15d | 2003-11-10 | 2003-11-28 |  | 2003-11-10 | 2003-11-28 | 15d | 79d |  | start no earlier than 2003-11-10 |
| 13 | 5.3 | Workflow,Roles/Bus Rules Doc |  | 15d | 2003-11-17 | 2003-12-05 |  | 2003-11-17 | 2003-12-05 | 15d | 74d |  | start no earlier than 2003-11-17 |
| 14 | 6 | Functional Requirements Summary Doc |  | 10d | 2003-12-08 | 2003-12-19 |  | 2003-12-08 | 2003-12-19 | 10d | 64d |  | start no earlier than 2003-12-08 |
| 15 | 7 | Deliverable: Func.& Tech Requirements | milestone | 0d | 2003-12-19 | 2003-12-19 | 14 | 2003-12-19 | 2003-12-19 | 0d? | 50d |  |  |
| 16 | 8 | **Technical Requirements Analysis** |  | 24d | 2003-11-04 | 2003-12-05 |  | 2003-11-04 | 2003-12-05 | 24d | 60d |  |  |
| 17 | 8.1 | Software/Hardware Infrastructure |  | 15d | 2003-11-04 | 2003-11-24 |  | 2003-11-04 | 2003-11-24 | 15d | 69d |  | start no earlier than 2003-11-04 |
| 18 | 8.2 | Web Issues |  | 10d | 2003-11-10 | 2003-11-21 |  | 2003-11-10 | 2003-11-21 | 10d | 70d |  | start no earlier than 2003-11-10 |
| 19 | 8.3 | Security Issues |  | 10d | 2003-11-10 | 2003-11-21 |  | 2003-11-10 | 2003-11-21 | 10d | 70d |  | start no earlier than 2003-11-10 |
| 20 | 8.4 | Network Issues |  | 15d | 2003-11-10 | 2003-11-28 |  | 2003-11-10 | 2003-11-28 | 15d | 65d |  | start no earlier than 2003-11-10 |
| 21 | 8.5 | Tech Requirements Doc |  | 15d | 2003-11-17 | 2003-12-05 |  | 2003-11-17 | 2003-12-05 | 15d | 60d |  | start no earlier than 2003-11-17 |
| 22 | 9 | **Database Programming/Configuration** |  | 54d | 2003-12-01 | 2004-02-12 |  | 2003-12-01 | 2004-02-12 | 54d | 11d |  |  |
| 23 | 9.1 | Trigger and Internal Stored Procedures (SPs) |  | 25d | 2003-12-01 | 2004-01-02 |  | 2003-12-01 | 2004-01-02 | 25d | 40d |  | start no earlier than 2003-12-01 |
| 24 | 9.2 | Application SPs |  | 38d | 2003-12-15 | 2004-02-04 |  | 2003-12-15 | 2004-02-04 | 38d | 17d |  | start no earlier than 2003-12-15 |
| 25 | 9.3 | Report SPs |  | 36d | 2003-12-25 | 2004-02-12 |  | 2003-12-25 | 2004-02-12 | 36d | 11d |  | start no earlier than 2003-12-25 |

| ID | WBS | Task | Type | Duration | Start | Finish | Predecessors | Baseline start | Baseline finish | Baseline duration | Total slack | Constraint |
| --- | --- | --- | --- | --- | --- | --- | --- | --- | --- | --- | --- | --- |
| 26 | 10 | **Application** |  | 75d | 2003-11-17 | 2004-02-27 |  | 2003-11-17 | 2004-02-27 | 75d | 0d |  |
| 27 | 10.1 | Front End |  | 25d | 2003-11-17 | 2003-12-19 |  | 2003-11-17 | 2003-12-19 | 25d | 50d | start no earlier than 2003-11-17 |
| 28 | 10.2 | Client Server Budget Formulation |  | 46d | 2003-12-01 | 2004-02-02 |  | 2003-12-01 | 2004-02-02 | 46d | 19d | start no earlier than 2003-12-01 |
| 29 | 10.3 | Web Budget Formulation |  | 53d | 2003-12-01 | 2004-02-11 |  | 2003-12-01 | 2004-02-11 | 53d | 12d | start no earlier than 2003-12-01 |
| 30 | 10.4 | Budget Publisher |  | 34d | 2003-12-29 | 2004-02-12 |  | 2003-12-29 | 2004-02-12 | 34d | 0d | start no earlier than 2003-12-29 |
| 31 | 10.5 | Reports |  | 29d | 2004-01-14 | 2004-02-23 |  | 2004-01-14 | 2004-02-23 | 29d | 4d | start no earlier than 2004-01-14 |
| 32 | 10.6 | Final configuration |  | 11d | 2004-02-13 | 2004-02-27 | 30 | 2004-02-13 | 2004-02-27 | 11d | 0d |  |
| 33 | 11 | **Integration with DOL Data Deliverables** |  | 46d | 2003-12-26 | 2004-03-01 |  | 2003-12-26 | 2004-03-01 | 46d | 0d | start no earlier than 2003-11-01 |
| 34 | 11.1 | First Show&Tell Prototype BF | milestone | 0d | 2003-12-26 | 2003-12-26 |  | 2003-12-26 | 2003-12-26 | 0d | 46d | start no earlier than 2003-12-26 |
| 35 | 11.2 | Functional Prototype BF | milestone | 0d | 2004-01-20 | 2004-01-20 |  | 2004-01-20 | 2004-01-20 | 0d | 29d | start no earlier than 2004-01-20 |
| 36 | 11.3 | Functional Prototype BP | milestone | 0d | 2004-02-02 | 2004-02-02 |  | 2004-02-02 | 2004-02-02 | 0d | 20d | start no earlier than 2004-02-02 |
| 37 | 11.4 | Final Application | milestone | 0d | 2004-03-01 | 2004-03-01 |  | 2004-03-01 | 2004-03-01 | 0d | 0d | start no earlier than 2004-03-01 |
| 38 | 12 | **User Documentation Preparation** |  | 50d | 2003-12-22 | 2004-02-27 |  | 2003-12-22 | 2004-02-27 | 50d | 0d |  |
| 39 | 12.1 | Manual |  | 50d | 2003-12-22 | 2004-02-27 |  | 2003-12-22 | 2004-02-27 | 50d | 0d | start no earlier than 2003-12-22 |
| 40 | 12.2 | Help System |  | 34d | 2004-01-05 | 2004-02-19 |  | 2004-01-05 | 2004-02-19 | 34d | 6d | start no earlier than 2004-01-05 |
| 41 | 13 | Support |  | 40d | 2004-01-05 | 2004-02-27 |  | 2004-01-05 | 2004-02-27 | 40d | 0d | start no earlier than 2004-01-05 |
| 42 | 14 | Training |  | 28d | 2004-01-16 | 2004-02-24 |  | 2004-01-16 | 2004-02-24 | 28d | 3d | start no earlier than 2004-01-16 |
| 43 | 15 | Installation |  | 10d? | 2004-02-02 | 2004-02-13 |  | 2004-02-02 | 2004-02-13 | 10d? | 10d | start no earlier than 2004-02-02 |
| 44 | 16 | **Management Meetings/Status Reports** |  | 71d | 2003-11-13 | 2004-02-19 |  | 2003-11-13 | 2004-02-19 | 71d | 6d |  |
| 45 | 16.1 | Management Meetings/Status Reports 1 |  | 1d | 2003-11-13 | 2003-11-13 |  | 2003-11-13 | 2003-11-13 | 1d | 76d | start no earlier than 2003-11-13 |
| 46 | 16.2 | Management Meetings/Status Reports 2 |  | 1d | 2003-11-27 | 2003-11-27 |  | 2003-11-27 | 2003-11-27 | 1d | 66d | start no earlier than 2003-11-27 |
| 47 | 16.3 | Management Meetings/Status Reports 3 |  | 1d | 2003-12-11 | 2003-12-11 |  | 2003-12-11 | 2003-12-11 | 1d | 56d | start no earlier than 2003-12-11 |
| 48 | 16.4 | Management Meetings/Status Reports 4 |  | 1d | 2003-12-25 | 2003-12-25 |  | 2003-12-25 | 2003-12-25 | 1d | 46d | start no earlier than 2003-12-25 |
| 49 | 16.5 | Management Meetings/Status Reports 5 |  | 1d | 2004-01-08 | 2004-01-08 |  | 2004-01-08 | 2004-01-08 | 1d | 36d | start no earlier than 2004-01-08 |
| 50 | 16.6 | Management Meetings/Status Reports 6 |  | 1d | 2004-01-22 | 2004-01-22 |  | 2004-01-22 | 2004-01-22 | 1d | 26d | start no earlier than 2004-01-22 |
| 51 | 16.7 | Management Meetings/Status Reports 7 |  | 1d | 2004-02-05 | 2004-02-05 |  | 2004-02-05 | 2004-02-05 | 1d | 16d | start no earlier than 2004-02-05 |
| 52 | 16.8 | Management Meetings/Status Reports 8 |  | 1d | 2004-02-19 | 2004-02-19 |  | 2004-02-19 | 2004-02-19 | 1d | 6d | start no earlier than 2004-02-19 |
